# JRA3-T1 WI 1.2 - Activity plan

Schedule from MS Project, 2014-01-06 to 2015-05-28, status date 2013-12-06, A marks actual dates.
HP

## Calendars

- Standard: Mon-Fri 09:00-13:00, 14:00-18:00; Sat-Sun off.

## Schedule

| ID | WBS | Task | Type | Duration | Start | Finish | Predecessors | Complete | Remaining | Total slack | Free slack |
| --- | --- | --- | --- | --- | --- | --- | --- | --- | --- | --- | --- |
| 1 | 1 | **Documentation phase** |  | 59d | 2014-01-06 A | 2014-03-27 A |  | 100% |  |  |  |
| 2 | 1.1 | Documentation on Grouper |  | 59d | 2014-01-06 A | 2014-03-27 A |  | 100% |  |  |  |
| 3 | 1.2 | Documentation on Grouper integration with Shibboleth |  | 25d | 2014-02-21 A | 2014-03-27 A | 2FF | 100% |  |  |  |
| 4 | 2 | **Feasibility (14 month, by 30/05/2014)** |  | 35d | 2014-03-28 A | 2014-05-15 A |  | 100% |  |  |  |
| 5 | 2.1 | Feasiblity report |  | 35d | 2014-03-28 A | 2014-05-15 A | 1 | 100% |  |  |  |
| 6 | 2.2 | Feasibility milestone | milestone | 0d | 2014-05-15 A | 2014-05-15 A | 5 | 100% |  |  |  |
| 7 | 3 | **Design (18 month, by 30/09/1024)** |  | 80d | 2014-06-03 A | 2014-09-22 |  | 91% | 6.86d | 178d |  |
| 8 | 3.1 | Solution design and architecture definition |  | 80d | 2014-06-03 A | 2014-09-22 A | 4FS+12d | 100% |  |  |  |
| 9 | 3.2 | Architecture for discovery |  | 60d | 2014-07-01 A | 2014-09-22 | 8FF | 80% | 12d | 178d | 0d |
| 10 | 3.3 | Design milestone | milestone | 0d | 2014-09-22 | 2014-09-22 | 9 |  |  | 178d |  |
| 11 | 4 | **Build (21 month, by 31/12/2014)** |  | 64d | 2014-10-02 A | 2014-12-30 |  | 70% | 19.12d | 0d |  |
| 12 | 4.1 | Installation of a Grouper instance |  | 5d | 2014-10-02 A | 2014-10-08 A | 7FS+7d | 100% |  |  |  |
| 13 | 4.2 | Integration of Grouper with a Shibboleth IdP |  | 1d | 2014-10-09 A | 2014-10-09 A | 12 | 100% |  |  |  |
| 14 | 4.3 | Configuration of Grouper as an Attribute Authority |  | 7d | 2014-10-10 A | 2014-10-20 A | 12, 13 | 100% |  |  |  |
| 15 | 4.4 | **Integrate Grouper with a wiki SP** |  | 23d | 2014-10-21 A | 2014-11-20 A |  | 100% |  |  |  |
| 16 | 4.4.1 | Integration of Grouper with a Shibboleth SP |  | 2d | 2014-10-21 A | 2014-10-22 A | 14 | 100% |  |  |  |
| 17 | 4.4.2 | Modifications of the wiki application to manage Grouper groups |  | 21d | 2014-10-23 A | 2014-11-20 A | 16 | 100% |  |  |  |
| 18 | 4.5 | **Integrate Grouper with a moodle SP** |  | 17d | 2014-11-21 A | 2014-12-15 A |  | 100% |  |  |  |
| 19 | 4.5.1 | Integration of Grouper with a Shibboleth SP |  | 1d | 2014-11-21 A | 2014-11-21 A | 15 | 100% |  |  |  |
| 20 | 4.5.2 | Modifications of the moodle application to manage Grouper groups |  | 16d | 2014-11-24 A | 2014-12-15 A | 19 | 100% |  |  |  |
| 21 | 4.6 | **Integrate Grouper with GARRbox SP** |  | 17d | 2014-11-24 A | 2014-12-16 |  | 1% | 16.9d | 3d | 0d |
| 22 | 4.6.1 | Integration of Grouper with a Shibboleth SP |  | 1d | 2014-12-16 A | 2014-12-16 | 18 | 10% | 0.9d | 3d |  |
| 23 | 4.6.2 | Modifications of the GARRbox application to manage Grouper groups |  | 16d | 2014-11-24 | 2014-12-15 | 19 |  |  | 4d |  |
| 24 | 4.7 | PoC documentation |  | 10d | 2014-12-17 A | 2014-12-30 | 15, 18, 21 | 30% | 7d | 0d |  |
| 25 | 4.8 | Build milestone | milestone | 0d | 2014-12-30 | 2014-12-30 | 24 |  |  | 0d |  |

Notes:
- 1: Investigate which problem could be solved by Grouper and what can reasonably be done on groups and attribute within Identity Federation.
- 4: Investigate the need for a discovery protocol for groups and / or attribute provider.
- 5: Deliverable JRA3T1-321
- 7: Design an architecture for a group and/or attribute exchange mechanism for discovering external attributes and/or groups (COULD BE one track for attributes and another on
- 9: Deliverable JRA3T1-322
- 11: Build at least one PoC
- 24: Deliverable JRA3T1-323

| ID | WBS | Task | Type | Duration | Start | Finish | Predecessors | Total slack | Constraint |
| --- | --- | --- | --- | --- | --- | --- | --- | --- | --- |
| 26 | 5 | **Finalize (24 month, by 31/03/2015)** |  | 105d | 2015-01-02 | 2015-05-28 |  | 0d |  |
| 27 | 5.1 | Deliverables for dissemination |  | 30d | 2015-01-02 | 2015-02-12 | 11FS+2d | 0d |  |
| 28 | 5.2 | Disseminate information |  | 60d | 2015-02-13 | 2015-05-07 | 27 | 0d |  |
| 29 | 5.3 | Project closure milestone | milestone | 0d | 2015-05-28 | 2015-05-28 | 28FS+15d | 0d | start no earlier than 2014-01-07 |

Notes:
- 26: Disseminate information to the wider audience (in GN3+ / HE&R / world)
- 27: Deliverable JRA3T1-324
